# BB-06 - met gietbouw hoogbouw

Schedule from MS Project, 2003-01-12 to 2003-02-23, status date 2003-01-08.
BAM Nelissen Van Egteren

## Calendars

- ALLEEN WERKDAGEN: Mon-Fri 08:30-12:30, 13:00-17:00; Sat-Sun off. Exceptions (off unless hours are given): 2003-01-11 to 2003-01-12 08:30-12:30, 13:00-17:00, 2003-01-18 to 2003-01-19 08:30-12:30, 13:00-17:00, 2003-01-25 to 2003-01-26 08:30-12:30, 13:00-17:00, 2003-02-01 to 2003-02-02 08:30-12:30, 13:00-17:00, 2003-02-08 to 2003-02-09 08:30-12:30, 13:00-17:00, 2003-02-15 to 2003-02-16 08:30-12:30, 13:00-17:00, 2003-02-22 to 2003-02-23 08:30-12:30, 13:00-17:00.

## Schedule

| ID | WBS | Task | Type | Duration | Start | Finish | Predecessors | Total slack |
| --- | --- | --- | --- | --- | --- | --- | --- | --- |
| 1 | 1 | **BOVENBOUWFASE** |  | 43d | 2003-01-12 | 2003-02-23 |  | 0d |
| 2 | 1.1 | beg.grond gietbouwwanden |  | 10d | 2003-01-12 | 2003-01-21 |  | 0d |
| 3 | 1.2 | 1e verd.vloer bekisting+wapening |  | 10d | 2003-01-15 | 2003-01-24 | 2SS+3d | 0d |
| 4 | 1.3 | 1e verd.vloer beton storten |  | 10d | 2003-01-18 | 2003-01-27 | 3SS+3d | 0d |
| 5 | 1.4 | 1e verd. gietbouwwanden |  | 10d | 2003-01-21 | 2003-01-30 | 4SS+3d | 0d |
| 6 | 1.5 | 2e verd.vloer bekisting+wapening |  | 10d | 2003-01-24 | 2003-02-02 | 5SS+3d | 0d |
| 7 | 1.6 | 2e verd.vloer beton storten |  | 10d | 2003-01-27 | 2003-02-05 | 6SS+3d | 0d |
| 8 | 1.7 | 2e verd. gietbouwwanden |  | 10d | 2003-01-30 | 2003-02-08 | 7SS+3d | 0d |
| 9 | 1.8 | 3e verd.vloer bekisting+wapening |  | 10d | 2003-02-02 | 2003-02-11 | 8SS+3d | 0d |
| 10 | 1.9 | 3e verd.vloer beton storten |  | 10d | 2003-02-05 | 2003-02-14 | 9SS+3d | 0d |
| 11 | 1.10 | 3e verd. gietbouwwanden |  | 10d | 2003-02-08 | 2003-02-17 | 10SS+3d | 0d |
| 12 | 1.11 | 4e verd.vloer bekisting+wapening |  | 10d | 2003-02-11 | 2003-02-20 | 11SS+3d | 0d |
| 13 | 1.12 | 4e verd.vloer beton storten |  | 10d | 2003-02-14 | 2003-02-23 | 12SS+3d | 0d |
| 14 | 1.13 | start gevel/dak fase | milestone | 0d | 2003-02-23 | 2003-02-23 | 13SS+10d | 0d |
